# High Level Plan for SAPBiz 9-24-08

Schedule from MS Project, 2008-09-26 to 2008-12-23.
MIT

## Calendars

- Standard: Mon-Fri 08:00-12:00, 13:00-17:00; Sat-Sun off. Exceptions (off unless hours are given): 2008-11-11, 2008-11-27 to 2008-11-28, 2008-12-06 08:00-12:00, 13:00-17:00.

## Resources

| Resource |
| --- |
| ABAP |
| BO |
| CAO |
| BASIS |
| BA |
| DEV |
| DWH |
| HR-P |
| ALL |
| 20 |
| BUS |
| 8 |
| 7 |

## Schedule

| ID | WBS | Task | Type | Duration | Start | Finish | Predecessors | Total slack | Free slack | Constraint | Resources | Work |
| --- | --- | --- | --- | --- | --- | --- | --- | --- | --- | --- | --- | --- |
| 1 | 1 | **2008 Support Pack Implementation Project** |  | 60d | 2008-09-26 | 2008-12-23 |  | 0d |  |  |  | 968h |
| 2 | 1.1 | **Project Prep** |  | 26d | 2008-09-26 | 2008-10-31 |  | 22d |  |  |  | 508h |
| 3 | 1.1.1 | Transaction list available | milestone | 0d | 2008-09-26 | 2008-09-26 |  | 35d | 1d | start no earlier than 2008-09-26 | BASIS |  |
| 4 | 1.1.2 | Identify test scenarios / transactions |  | 5d | 2008-09-29 | 2008-10-03 | 3 | 34d | 0d | start no earlier than 2008-09-29 | BUS; BA | 80h |
| 5 | 1.1.3 | Review and update test scripts |  | 20d | 2008-10-06 | 2008-10-31 | 4 | 34d |  |  | BUS; BA | 320h |
| 6 | 1.1.4 | Production snapshot at end of day (9/22 or 10/20?) | milestone | 0d | 2008-10-20 | 2008-10-20 |  | 42.5d | 0d | start no earlier than 2008-10-20 | BASIS |  |
| 7 | 1.1.5 | Execute Trial balance for snapshot |  | 0.5d | 2008-10-20 | 2008-10-20 | 6 | 42.5d | 0d | start no earlier than 2008-10-20 | BUS | 4h |
| 8 | 1.1.6 | Save data warehouse extracts |  | 1d | 2008-10-20 | 2008-10-21 | 7 | 42.5d |  |  | DWH | 8h |
| 9 | 1.1.7 | Support packs available from SAP | milestone | 0d | 2008-10-20 | 2008-10-20 |  | 9.5d | 0d | start no earlier than 2008-10-20 |  |  |
| 10 | 1.1.8 | Apply support packs in SF3, collision report produced |  | 3d | 2008-10-20 | 2008-10-22 | 9 | 9.5d | 0d |  | BASIS | 24h |
| 11 | 1.1.9 | Analyze collision report, reimplement mods, identify any changes to action log |  | 3d | 2008-10-23 | 2008-10-27 | 10 | 9.5d | 0d |  | BA; DEV; BASIS | 72h |
| 12 | 1.2 | **Unit Test Preparation and Execution** |  | 13d | 2008-10-28 | 2008-11-14 | 11 | 6d |  |  |  | 188h |
| 13 | 1.2.1 | Apply support packs to SF2 |  | 2d | 2008-10-28 | 2008-10-29 |  | 25d | 0d |  | BASIS | 16h |
| 14 | 1.2.2 | Reimplement MIT mods |  | 0.5d | 2008-10-30 | 2008-10-30 | 13 | 25d | 0d |  | DEV | 4h |
| 15 | 1.2.3 | Update and Execute action log |  | 0.5d | 2008-10-30 | 2008-10-30 | 14 | 25d | 0d |  | BA; DEV | 8h |
| 16 | 1.2.4 | Unit test in SF2 |  | 5d | 2008-10-31 | 2008-11-06 | 15 | 25d | 0d |  | BA; DEV | 80h |
| 17 | 1.2.5 | Issue resolution and retest |  | 5d | 2008-11-07 | 2008-11-14 | 16 | 25d |  |  | BA; DEV | 80h |
| 18 | 1.3 | **Regression Test Environment Preparations** |  | 8d | 2008-10-31 | 2008-11-12 |  | 6d |  |  |  | 72h |
| 19 | 1.3.1 | Refresh ### with snapshot |  | 4d | 2008-10-31 | 2008-11-05 | 15 | 6d | 0d |  | BASIS | 32h |
| 20 | 1.3.2 | Apply support packs |  | 2d | 2008-11-06 | 2008-11-07 | 19 | 6d | 0d |  | BASIS | 16h |
| 21 | 1.3.3 | Reimplement MIT mods |  | 0.5d | 2008-11-10 | 2008-11-10 | 20 | 6d | 0d |  | DEV | 4h |
| 22 | 1.3.4 | Execute action log |  | 0.5d | 2008-11-10 | 2008-11-10 | 21 | 6d | 0d |  | DEV; BA | 8h |
| 23 | 1.3.5 | Execute trial balance and compare with TB from 10/20 |  | 0.5d | 2008-11-12 | 2008-11-12 | 22 | 27.5d | 0d |  | BUS | 4h |
| 24 | 1.3.6 | Development slowdown starts | milestone | 0d | 2008-11-12 | 2008-11-12 | 23 | 27.5d |  |  |  |  |
| 25 | 1.3.7 | Apply post refresh production transports |  | 1d | 2008-11-12 | 2008-11-12 | 22 | 6d | 0d |  | BASIS | 8h |

| ID | WBS | Task | Type | Duration | Start | Finish | Predecessors | Total slack | Free slack | Constraint | Resources | Work |
| --- | --- | --- | --- | --- | --- | --- | --- | --- | --- | --- | --- | --- |
| 26 | 1.4 | **Execute Regression Tests** |  | 19d | 2008-11-13 | 2008-12-10 |  | 6d |  |  |  | 184h |
| 27 | 1.4.1 | Data Warehouse extracts and comparison |  | 1d | 2008-11-13 | 2008-11-13 | 25 | 6d | 0d |  | DWH; BASIS | 16h |
| 28 | 1.4.2 | Payroll comparison (duration to be validated) |  | 3d | 2008-11-14 | 2008-11-18 | 27 | 6d | 0d |  | BA; BUS | 48h |
| 29 | 1.4.3 | Financial Close of prior period (Just 10/08 or 9/08 & 10/08?) |  | 1d | 2008-11-19 | 2008-11-19 | 28 | 6d | 0d |  | BUS | 8h |
| 30 | 1.4.4 | Execute regression tests |  | 8d | 2008-11-20 | 2008-12-03 | 29 | 6d | 0d |  | BUS | 64h |
| 31 | 1.4.5 | Financial Close of 11/08 |  | 1d | 2008-12-04 | 2008-12-04 | 30 | 6d | 0d |  | BUS | 8h |
| 32 | 1.4.6 | Issue retesting |  | 3d | 2008-12-05 | 2008-12-08 | 31 | 6d | 0d |  | ALL | 24h |
| 33 | 1.4.7 | Execute another financial close? |  | 1d | 2008-12-09 | 2008-12-09 | 32 | 6d | 0d |  | BUS | 8h |
| 34 | 1.4.8 | Regression test sign off |  | 1d | 2008-12-10 | 2008-12-10 | 33 | 6d | 0d |  | ALL | 8h |
| 35 | 1.5 | Cutover weekend & Controlled Start |  | 2d | 2008-12-11 | 2008-12-12 | 34 | 6d |  | finish no earlier than 2008-12-08 | ALL | 16h |
| 36 | 1.6 | Drop Dead Date for support packs in production | milestone | 0d | 2008-12-22 | 2008-12-22 |  | 1d |  | start no earlier than 2008-12-22 |  |  |
| 37 | 1.7 | First Calendar 2009 Payroll | milestone | 0d | 2008-12-23 | 2008-12-23 |  | 0d |  | start no earlier than 2008-12-23 |  |  |
